# GPProject

Schedule from MS Project, 2013-10-10 to 2014-03-31, costs in $.

## Calendars

- Standard: Mon-Fri 08:00-12:00, 13:00-17:00; Sat-Sun off.

## Resources

| Resource | Rate |
| --- | --- |
| Artist1 | 18.75 |
| Artist2 | 18.75 |
| Artist3 | 18.75 |
| QA1 | 18 |
| QA2 | 18 |
| Designer1 | 18.75 |
| Designer2 | 18.75 |
| Designer3 | 18.75 |
| Programmer1 | 31.25 |
| Programmer2 | 31.25 |
| Programmer3 | 31.25 |
| Artist4 | 18.75 |

## Schedule

| ID | WBS | Task | Duration | Start | Finish | Total slack | Constraint |
| --- | --- | --- | --- | --- | --- | --- | --- |
| 1 | 1 | **Programing** | 82d | 2013-10-10 | 2014-01-31 | 41d |  |
| 2 | 1.1 | prototype code | 12d | 2013-10-10 | 2013-10-25 | 75d | start no earlier than 2013-10-10 |
| 3 | 1.2 | build prototype | 3d | 2013-10-22 | 2013-10-24 | 76d | start no earlier than 2013-10-22 |
| 4 | 1.3 | test GUI with script | 2d | 2013-10-24 | 2013-10-25 | 75d | start no earlier than 2013-10-24 |
| 5 | 1.4 | implement GUI with script feedback | 2d | 2013-10-28 | 2013-10-29 | 73d | start no earlier than 2013-10-26 |
| 6 | 1.5 | create animation script prototypes | 10d | 2013-11-05 | 2013-11-18 | 59d | start no earlier than 2013-11-05 |
| 7 | 1.6 | test prototypes | 2d | 2013-11-07 | 2013-11-08 | 65d | start no earlier than 2013-11-07 |
| 8 | 1.7 | implement prototype feedback | 3d | 2013-11-11 | 2013-11-13 | 62d | start no earlier than 2013-11-10 |
| 9 | 1.8 | create level puzzle script prototype | 3d | 2013-11-13 | 2013-11-15 | 60d | start no earlier than 2013-11-13 |
| 10 | 1.9 | test script in prototype level | 2d | 2013-11-15 | 2013-11-18 | 59d | start no earlier than 2013-11-15 |
| 11 | 1.10 | implement level puzzle feedback | 4d | 2013-11-20 | 2013-11-25 | 54d | start no earlier than 2013-11-20 |
| 12 | 1.11 | script first pass of mission scripting | 2d | 2013-11-21 | 2013-11-22 | 55d | start no earlier than 2013-11-21 |
| 13 | 1.12 | implement feedback from quest scripting | 2d | 2013-11-21 | 2013-11-22 | 55d | start no earlier than 2013-11-21 |
| 14 | 1.13 | create traps script, environment tiles randomizer prototypes | 5d | 2013-11-28 | 2013-12-04 | 47d | start no earlier than 2013-11-28 |
| 15 | 1.14 | program traps, environment tile prototypes | 5d | 2013-12-05 | 2013-12-11 | 42d | start no earlier than 2013-12-05 |
| 16 | 1.15 | test test traps, environment tiles | 2d | 2013-12-09 | 2013-12-10 | 43d | start no earlier than 2013-12-07 |
| 17 | 1.16 | implement feedback from traps,environment scripting | 3d | 2013-12-10 | 2013-12-12 | 41d | start no earlier than 2013-12-10 |
| 18 | 1.17 | create custom character stats | 4d | 2013-12-16 | 2013-12-19 | 36d | start no earlier than 2013-12-14 |
| 19 | 1.18 | test out stat controller | 2d | 2013-12-16 | 2013-12-17 | 38d | start no earlier than 2013-12-16 |
| 20 | 1.19 | implement customized character test | 3d | 2013-12-19 | 2013-12-23 | 34d | start no earlier than 2013-12-19 |
| 21 | 1.20 | script first pass of multiplayer scripting | 5d | 2013-12-24 | 2013-12-30 | 29d | start no earlier than 2013-12-24 |
| 22 | 1.21 | implement any changes from multiplayer script tests | 3d | 2013-12-24 | 2013-12-26 | 31d | start no earlier than 2013-12-24 |
| 23 | 1.22 | create monster enemy prototypes round 1 | 4d | 2013-12-31 | 2014-01-03 | 25d | start no earlier than 2013-12-31 |
| 24 | 1.23 | test monster enemy scripts | 2d | 2014-01-02 | 2014-01-03 | 25d | start no earlier than 2014-01-02 |
| 25 | 1.24 | implement feedback from monster enemy scripts | 3d | 2014-01-06 | 2014-01-08 | 22d | start no earlier than 2014-01-05 |
| 26 | 1.25 | finalize monster round 1 models | 5d | 2014-01-10 | 2014-01-16 | 16d | start no earlier than 2014-01-10 |
| 27 | 1.26 | create monster enemy prototypes round 2 | 1d | 2014-01-13 | 2014-01-13 | 19d | start no earlier than 2014-01-11 |
| 28 | 1.27 | test monster enemy scripts | 2d | 2014-01-13 | 2014-01-14 | 18d | start no earlier than 2014-01-12 |
| 29 | 1.28 | implement feedback from monster enemy scripts | 3d | 2014-01-15 | 2014-01-17 | 15d | start no earlier than 2014-01-15 |
| 30 | 1.29 | finalize monster round 2 models | 5d | 2014-01-20 | 2014-01-24 | 10d | start no earlier than 2014-01-20 |
| 31 | 1.30 | create healing items prototypes | 5d | 2014-01-27 | 2014-01-31 | 5d | start no earlier than 2014-01-25 |
| 32 | 1.31 | test healing items scripts | 2d | 2014-01-27 | 2014-01-28 | 8d | start no earlier than 2014-01-27 |
| 33 | 1.32 | implement feedback from script test | 2d | 2014-01-28 | 2014-01-29 | 7d | start no earlier than 2014-01-28 |

Notes:
- 1: Engineers around $5,500

| ID | WBS | Task | Duration | Start | Finish | Total slack | Constraint |
| --- | --- | --- | --- | --- | --- | --- | --- |
| 34 | 2 | **Sound** | 52d | 2013-10-24 | 2014-01-03 | 61d |  |
| 35 | 2.1 | Menu start/load music | 4d | 2013-10-24 | 2013-10-29 | 73d |  |
| 36 | 2.2 | Beginner level music | 6d | 2013-10-30 | 2013-11-06 | 67d | start no earlier than 2013-10-30 |
| 37 | 2.3 | Menu sound fx set (5 sounds) | 4d | 2013-11-07 | 2013-11-12 | 63d | start no earlier than 2013-11-07 |
| 38 | 2.4 | Basic Battle sound fx set 1 (5 sounds) | 6d | 2013-11-13 | 2013-11-20 | 57d | start no earlier than 2013-11-13 |
| 39 | 2.5 | World interaction sound set 1 (5 sounds) | 4d | 2013-11-21 | 2013-11-26 | 53d | start no earlier than 2013-11-21 |
| 40 | 2.6 | Character voice sound fx set 1 (5 sounds) | 6d | 2013-11-27 | 2013-12-04 | 47d | start no earlier than 2013-11-27 |
| 41 | 2.7 | Monster call sound fx set 1 (5 sounds) | 5d | 2013-12-05 | 2013-12-11 | 42d | start no earlier than 2013-12-05 |
| 42 | 2.8 | Novice level music | 5d | 2013-12-12 | 2013-12-18 | 37d | start no earlier than 2013-12-12 |
| 43 | 2.9 | Lvl up music | 3d | 2013-12-19 | 2013-12-23 | 34d | start no earlier than 2013-12-19 |
| 44 | 2.10 | Weather sound fx set (3 sounds) | 3d | 2014-01-01 | 2014-01-03 | 25d | start no earlier than 2014-01-01 |
| 45 | 2.11 | Song set 1 (3 songs) | 2w | 2013-10-24 | 2013-11-06 | 67d |  |
| 46 | 2.12 | Song set 2 (3 songs) | 2w | 2013-10-24 | 2013-11-06 | 67d |  |
| 47 | 2.13 | Song set 3 (3 songs) | 2w | 2013-10-24 | 2013-11-06 | 67d |  |
| 48 | 2.14 | Basic Battle sound fx set 2 (5 sounds) | 5d | 2013-10-24 | 2013-10-30 | 72d |  |
| 49 | 2.15 | Advanced Battle set fx (3 sounds) | 5d | 2013-10-24 | 2013-10-30 | 72d |  |
| 50 | 2.16 | Character voice sound fx set 2 (5 sounds) | 5d | 2013-10-24 | 2013-10-30 | 72d |  |
| 51 | 2.17 | Monster call sound fx set 2 (5 sounds) | 5d | 2013-10-24 | 2013-10-30 | 72d |  |
| 52 | 2.18 | Monster call sound fx set 3 (5 sounds) | 5d | 2013-10-24 | 2013-10-30 | 72d |  |
| 53 | 2.19 | World interaction sound set 2 (5 sounds) | 5d | 2013-10-24 | 2013-10-30 | 72d |  |
| 54 | 2.20 | World interaction sound set 3 (5 sounds) | 5d | 2013-10-24 | 2013-10-30 | 72d |  |
| 55 | 2.21 | Extra sound fx set 1 (10 sounds) | 10d | 2013-10-24 | 2013-11-06 | 67d |  |
| 56 | 2.22 | Extra sound fx set 2 (10 sounds) | 10d | 2013-10-24 | 2013-11-06 | 67d |  |
| 57 | 2.23 | Clean up sounds | 3d | 2013-10-24 | 2013-10-28 | 74d |  |
| 58 | 2.24 | Clean up music | 5d | 2013-10-24 | 2013-10-30 | 72d |  |

Notes:
- 34: VG Sound engineers $35,000 a year - $3000 a month
- 35: assistant engineer earns about $18,000 to $28,000 a year

| ID | WBS | Task | Duration | Start | Finish | Total slack |
| --- | --- | --- | --- | --- | --- | --- |
| 59 | 3 | **QA Testing** | 12d | 2013-10-24 | 2013-11-08 | 101d |
| 60 | 3.1 | Create Testing Bible | 10d | 2013-10-24 | 2013-11-06 | 67d |
| 61 | 3.2 | Test GUI round 1 | 3d | 2013-10-24 | 2013-10-28 | 74d |
| 62 | 3.3 | Test GUI round 2 | 2d | 2013-10-24 | 2013-10-25 | 75d |
| 63 | 3.4 | Test character movement/models/animation round 1 | 12d | 2013-10-24 | 2013-11-08 | 65d |
| 64 | 3.5 | Test character movement/models/animation round 2 | 12d | 2013-10-24 | 2013-11-08 | 65d |
| 65 | 3.6 | Test level terrain round 1 | 7d | 2013-10-24 | 2013-11-01 | 70d |
| 66 | 3.7 | Test level terrain round 2 | 7d | 2013-10-24 | 2013-11-01 | 70d |
| 67 | 3.8 | Test out dialog and quest system round 1 | 10d | 2013-10-24 | 2013-11-06 | 67d |
| 68 | 3.9 | Test out dialog and quest system round 2 | 10d | 2013-10-24 | 2013-11-06 | 67d |
| 69 | 3.10 | Test trap system round 1 | 5d | 2013-10-24 | 2013-10-30 | 72d |
| 70 | 3.11 | Test trap system round 2 | 5d | 2013-10-24 | 2013-10-30 | 72d |
| 71 | 3.12 | Test dungeon generator round 1 | 6d | 2013-10-24 | 2013-10-31 | 71d |
| 72 | 3.13 | Test dungeon generator round 2 | 6d | 2013-10-24 | 2013-10-31 | 71d |
| 73 | 3.14 | Test customized character round 1 | 7d | 2013-10-24 | 2013-11-01 | 70d |
| 74 | 3.15 | Test customized character round 2 | 7d | 2013-10-24 | 2013-11-01 | 70d |
| 75 | 3.16 | Test monster fight round 1 | 5d | 2013-10-24 | 2013-10-30 | 72d |
| 76 | 3.17 | Test monster fight round 2 | 5d | 2013-10-24 | 2013-10-30 | 72d |
| 77 | 3.18 | Test multiplayer round 1 | 5d | 2013-10-24 | 2013-10-30 | 72d |
| 78 | 3.19 | Test multiplayer round 2 | 5d | 2013-10-24 | 2013-10-30 | 72d |
| 79 | 3.20 | Test monster fight 2 round 1 | 5d | 2013-10-24 | 2013-10-30 | 72d |
| 80 | 3.21 | Test monster fight 2 round 2 | 5d | 2013-10-24 | 2013-10-30 | 72d |
| 81 | 3.22 | Test healing items round 1 | 3d | 2013-10-24 | 2013-10-28 | 74d |
| 82 | 3.23 | Test healing items round 2 | 3d | 2013-10-24 | 2013-10-28 | 74d |
| 83 | 3.24 | Test multiplayer 2 round 1 | 4d | 2013-10-24 | 2013-10-29 | 73d |
| 84 | 3.25 | Test multiplayer 2 round 2 | 4d | 2013-10-24 | 2013-10-29 | 73d |
| 85 | 3.26 | Test special effects round 1 | 3d | 2013-10-24 | 2013-10-28 | 74d |
| 86 | 3.27 | Test special effects round 2 | 3d | 2013-10-24 | 2013-10-28 | 74d |
| 87 | 3.28 | Test monster fight 3 round 1 | 4d | 2013-10-24 | 2013-10-29 | 73d |
| 88 | 3.29 | Test monster fight3 round 2 | 4d | 2013-10-24 | 2013-10-29 | 73d |

Notes:
- 59: About $15 an dollar hour
- 60: lead $35 an hour

| ID | WBS | Task | Duration | Start | Finish | Predecessors | Total slack | Free slack | Constraint | Resources | Work | Cost |
| --- | --- | --- | --- | --- | --- | --- | --- | --- | --- | --- | --- | --- |
| 89 | 4 | **Art** | 86d? | 2013-10-10 | 2014-02-06 |  | 37d |  |  |  | 992h | 18,600 |
| 90 | 4.1 | Concept art | 12d | 2013-10-10 | 2013-10-25 |  | 111d |  | start no earlier than 2013-10-10 | Artist1; Artist2 [50%] | 144h | 2,700 |
| 91 | 4.2 | **GUI Art** | 10d | 2013-10-24 | 2013-11-06 |  | 103d |  |  | Artist3 | 80h | 1,500 |
| 92 | 4.2.1 | Create GUI art | 3d | 2013-10-24 | 2013-10-28 |  | 106d | 3d |  |  |  |  |
| 93 | 4.2.2 | Test GUI art | 2d | 2013-11-01 | 2013-11-04 | 92 | 103d | 0d | start no earlier than 2013-11-01 |  |  |  |
| 94 | 4.2.3 | Implement GUI with script feedback | 2d | 2013-11-05 | 2013-11-06 | 93 | 103d |  |  |  |  |  |
| 95 | 4.3 | **Main Character Models** | 18d | 2013-11-06 | 2013-11-29 |  | 86d |  |  | Artist4 | 144h | 2,700 |
| 96 | 4.3.1 | Create character model w/animation prototype | 10d | 2013-11-06 | 2013-11-19 |  | 86d | 0d | start no earlier than 2013-11-06 |  |  |  |
| 97 | 4.3.2 | Test prototype | 2d | 2013-11-20 | 2013-11-21 | 96 | 86d | 0d |  |  |  |  |
| 98 | 4.3.3 | Implement prototype feedback | 3d | 2013-11-22 | 2013-11-26 | 97 | 86d | 0d |  |  |  |  |
| 99 | 4.3.4 | Create model textures | 3d | 2013-11-27 | 2013-11-29 | 98 | 86d |  |  |  |  |  |
| 100 | 4.4 | **Level 1 Environment Models** | 9d | 2013-10-30 | 2013-11-11 |  | 100d |  |  | Artist2 [50%] | 36h | 675 |
| 101 | 4.4.1 | Create Level 1 Environment Models | 3d | 2013-10-30 | 2013-11-01 |  | 100d | 0d | start no earlier than 2013-10-30 |  |  |  |
| 102 | 4.4.2 | Test models in prototype level | 2d | 2013-11-04 | 2013-11-05 | 101 | 100d | 0d |  |  |  |  |
| 103 | 4.4.3 | Implement level prototype feedback | 4d | 2013-11-06 | 2013-11-11 | 102 | 100d |  |  |  |  |  |
| 104 | 4.5 | **Inventory Menu Art** | 6d | 2013-11-11 | 2013-11-18 |  | 95d |  |  | Artist1 | 48h | 900 |
| 105 | 4.5.1 | Create font, background and item art | 2d | 2013-11-11 | 2013-11-12 |  | 95d | 0d | start no earlier than 2013-11-11 |  |  |  |
| 106 | 4.5.2 | Test Inventory Art | 2d | 2013-11-13 | 2013-11-14 | 105 | 95d | 0d |  |  |  |  |
| 107 | 4.5.3 | Implement Feedback from Inventory Art Test | 2d | 2013-11-15 | 2013-11-18 | 106 | 95d |  |  |  |  |  |
| 108 | 4.6 | **Weapons + Stat Tiles** | 13d | 2013-11-11 | 2013-11-27 |  | 88d |  |  | Artist3 | 104h | 1,950 |
| 109 | 4.6.1 | Create Weapons + Stat Tiles Art | 7d | 2013-11-11 | 2013-11-19 |  | 88d | 0d | start no earlier than 2013-11-11 |  |  |  |
| 110 | 4.6.2 | Test Weapon/Stat Tile Art | 3d | 2013-11-20 | 2013-11-22 | 109 | 88d | 0d |  |  |  |  |
| 111 | 4.6.3 | Implement Feedback from Weapon/Stat Tile Test | 3d | 2013-11-25 | 2013-11-27 | 110 | 88d |  |  |  |  |  |
| 112 | 4.7 | **Custom Character Assests** | 9d | 2013-11-28 | 2013-12-10 |  | 79d |  |  | Artist2 [50%] | 36h | 675 |
| 113 | 4.7.1 | Create custom character assets | 4d | 2013-11-28 | 2013-12-03 |  | 79d | 0d | start no earlier than 2013-11-28 |  |  |  |
| 114 | 4.7.2 | Test customized character test | 2d | 2013-12-04 | 2013-12-05 | 113 | 79d | 0d |  |  |  |  |
| 115 | 4.7.3 | Implement customized character feedback | 3d | 2013-12-06 | 2013-12-10 | 114 | 79d |  |  |  |  |  |
| 116 | 4.8 | Catch up day | 1d | 2013-12-11 | 2013-12-11 |  | 78d |  | start no earlier than 2013-12-11 | Artist1; Artist2 [50%]; Artist3; Artist4 | 28h | 525 |

Notes:
- 89: Pixel Artist average is $30 an hour...
- 90: Modeler average is $45,000 a year

| ID | WBS | Task | Duration | Start | Finish | Predecessors | Total slack | Free slack | Constraint | Resources | Work | Cost |
| --- | --- | --- | --- | --- | --- | --- | --- | --- | --- | --- | --- | --- |
| 117 | 4.9 | **Enemy Model Set 1** | 18d | 2013-12-12 | 2014-01-06 |  | 60d |  |  | Artist2 [50%] | 72h | 1,350 |
| 118 | 4.9.1 | Create monster enemy models round 1 | 4d | 2013-12-12 | 2013-12-17 |  | 69d | 0d | start no earlier than 2013-12-12 |  |  |  |
| 119 | 4.9.2 | Test monster enemy models | 2d | 2013-12-18 | 2013-12-19 | 118 | 69d | 0d |  |  |  |  |
| 120 | 4.9.3 | Implement feedback from monster enemy test | 3d | 2013-12-20 | 2013-12-24 | 119 | 69d |  |  |  |  |  |
| 121 | 4.9.4 | Create model textures | 3d | 2014-01-02 | 2014-01-06 |  | 60d |  | start no earlier than 2014-01-02 |  |  |  |
| 122 | 4.10 | **Enemy Model Set 2** | 12d | 2014-01-07 | 2014-01-22 |  | 47d | 0d |  | Artist1 | 96h | 1,800 |
| 123 | 4.10.1 | Create monster enemy models round 2 | 4d | 2014-01-07 | 2014-01-10 |  | 47d | 0d | start no earlier than 2014-01-07 |  |  |  |
| 124 | 4.10.2 | Test monster enemy models | 2d | 2014-01-13 | 2014-01-14 | 123 | 47d | 0d |  |  |  |  |
| 125 | 4.10.3 | Implement feedback from monster enemy test | 3d | 2014-01-15 | 2014-01-17 | 124 | 47d | 0d |  |  |  |  |
| 126 | 4.10.4 | Create model textures | 3d | 2014-01-20 | 2014-01-22 | 125 | 47d |  |  |  |  |  |
| 127 | 4.11 | Catch up day | 1d | 2014-01-23 | 2014-01-23 | 122 | 47d |  |  | Artist1; Artist2 [50%]; Artist3; Artist4 | 28h | 525 |
| 128 | 4.12 | **Healing items** | 11d | 2014-01-23 | 2014-02-06 |  | 37d |  |  | Artist3; Artist4 | 176h | 3,300 |
| 129 | 4.12.1 | Create healing item models | 5d | 2014-01-23 | 2014-01-29 |  | 37d | 0d | start no earlier than 2014-01-23 |  |  |  |
| 130 | 4.12.2 | Test healing items models | 2d | 2014-01-30 | 2014-01-31 | 129 | 37d | 0d |  |  |  |  |
| 131 | 4.12.3 | Implement feedback from healing test | 2d | 2014-02-03 | 2014-02-04 | 130 | 37d | 0d |  |  |  |  |
| 132 | 4.12.4 | Create textures | 2d | 2014-02-05 | 2014-02-06 | 131 | 37d |  |  |  |  |  |
| 133 | 4.13 | Create special effects round 1 | 5d | 2013-10-24 | 2013-10-30 |  | 108d |  |  |  |  |  |
| 134 | 4.14 | Test special effects | 2d | 2013-10-24 | 2013-10-25 |  | 111d |  |  |  |  |  |
| 135 | 4.15 | Implement feedback from special effects | 5d | 2013-10-24 | 2013-10-30 |  | 108d |  |  |  |  |  |
| 136 | 4.16 | Create monster enemy models round 3 | 4d | 2013-10-24 | 2013-10-29 |  | 109d |  |  |  |  |  |
| 137 | 4.17 | Test monster enemy models | 3d | 2013-10-24 | 2013-10-28 |  | 110d |  |  |  |  |  |
| 138 | 4.18 | Implement feedback from monster enemy test | 3d | 2013-10-24 | 2013-10-28 |  | 110d |  |  |  |  |  |
| 139 | 4.19 | Finalize monster round 3 models | 3d | 2013-10-24 | 2013-10-28 |  | 110d |  |  |  |  |  |
| 140 | 4.20 | Create texture set 1 | 1d? | 2013-10-24 | 2013-10-24 |  | 112d |  |  |  |  |  |
| 141 | 4.21 | Create texture set 2 | 1d? | 2013-10-24 | 2013-10-24 |  | 112d |  |  |  |  |  |

| ID | WBS | Task | Duration | Start | Finish | Predecessors | Total slack | Free slack | Constraint | Resources | Work | Cost |
| --- | --- | --- | --- | --- | --- | --- | --- | --- | --- | --- | --- | --- |
| 142 | 5 | **Approvals** | 1d? | 2013-10-24 | 2013-10-24 |  | 112d |  |  |  |  |  |
| 143 | 5.1 | Alpha | 1d? | 2013-10-24 | 2013-10-24 |  | 112d |  |  |  |  |  |
| 144 | 5.2 | Finalize Art | 1d? | 2013-10-24 | 2013-10-24 |  | 112d |  |  |  |  |  |
| 145 | 5.3 | Code Freeze | 1d? | 2013-10-24 | 2013-10-24 |  | 112d |  |  |  |  |  |
| 146 | 5.4 | Beta | 1d? | 2013-10-24 | 2013-10-24 |  | 112d |  |  |  |  |  |
| 147 | 5.5 | Gold | 1d? | 2013-10-24 | 2013-10-24 |  | 112d |  |  |  |  |  |
| 148 | 5.6 | Ship | 1d? | 2013-10-24 | 2013-10-24 |  | 112d |  |  |  |  |  |
| 149 | 6 | **Design** | 123d | 2013-10-10 | 2014-03-31 |  | 0d |  |  |  | 983.84h | 18,447 |
| 150 | 6.1 | **Battle System Prototype** | 5d | 2013-10-10 | 2013-10-16 |  | 118d |  |  | Designer1 | 40h | 750 |
| 151 | 6.1.1 | Build small paper prototype of battle system | 2d | 2013-10-10 | 2013-10-11 |  | 118d | 0d | start no earlier than 2013-10-09 |  |  |  |
| 152 | 6.1.2 | Test out prototype | 1d | 2013-10-14 | 2013-10-14 | 151 | 118d | 0d |  |  |  |  |
| 153 | 6.1.3 | Adjust prototype | 2d | 2013-10-15 | 2013-10-16 | 152 | 118d |  |  |  |  |  |
| 154 | 6.2 | **GUI Setup Prototype** | 7d | 2013-10-17 | 2013-10-25 |  | 111d |  |  | Designer2 | 56h | 1,050 |
| 155 | 6.2.1 | Create GUI prototypes | 3d | 2013-10-17 | 2013-10-21 |  | 111d | 0d | start no earlier than 2013-10-17 |  |  |  |
| 156 | 6.2.2 | Test GUI with script | 2d | 2013-10-22 | 2013-10-23 | 155 | 111d | 0d | start no earlier than 2013-10-22 |  |  |  |
| 157 | 6.2.3 | Adjust GUI from feedback | 2d | 2013-10-24 | 2013-10-25 | 156 | 111d |  | start no earlier than 2013-10-24 |  |  |  |
| 158 | 6.3 | **Character Stats Prototype** | 9d | 2013-10-28 | 2013-11-07 |  | 102d |  |  | Designer3 | 72h | 1,350 |
| 159 | 6.3.1 | Define set character stats in protoype | 4d | 2013-10-28 | 2013-10-31 |  | 102d | 0d | start no earlier than 2013-10-28 |  |  |  |
| 160 | 6.3.2 | Test stat battle round 1 | 2d | 2013-11-01 | 2013-11-04 | 159 | 102d | 0d |  |  |  |  |
| 161 | 6.3.3 | Implement prototype feedback | 3d | 2013-11-05 | 2013-11-07 | 160 | 102d |  | start no earlier than 2013-11-04 |  |  |  |
| 162 | 6.4 | **Level 1 Terrain Layout** | 9d | 2013-11-08 | 2013-11-20 |  | 93d |  |  | Designer1 | 72h | 1,350 |
| 163 | 6.4.1 | Create level 1 layout prototype | 3d | 2013-11-08 | 2013-11-12 |  | 93d | 0d | start no earlier than 2013-11-08 |  |  |  |
| 164 | 6.4.2 | Test models in prototype level | 2d | 2013-11-13 | 2013-11-14 | 163 | 93d | 0d |  |  |  |  |
| 165 | 6.4.3 | Implement level prototype feedback | 4d | 2013-11-15 | 2013-11-20 | 164 | 93d |  |  |  |  |  |

| ID | WBS | Task | Duration | Start | Finish | Predecessors | Total slack | Free slack | Constraint | Resources | Work | Cost |
| --- | --- | --- | --- | --- | --- | --- | --- | --- | --- | --- | --- | --- |
| 166 | 6.5 | **Inventory Prototype** | 10d | 2013-11-21 | 2013-12-04 |  | 83d |  |  | Designer2 | 80h | 1,500 |
| 167 | 6.5.1 | Create inventory prototype | 5d | 2013-11-21 | 2013-11-27 |  | 83d | 0d | start no earlier than 2013-11-21 |  |  |  |
| 168 | 6.5.2 | Test inventory prototype | 2d | 2013-11-28 | 2013-11-29 | 167 | 83d | 0d |  |  |  |  |
| 169 | 6.5.3 | Implement inventory prototype feedback | 3d | 2013-12-02 | 2013-12-04 | 168 | 83d |  |  |  |  |  |
| 170 | 6.6 | Catch up day | 1d | 2013-12-05 | 2013-12-05 |  | 82d |  | start no earlier than 2013-12-05 | Designer3 [33.3%]; Designer1 [33.3%]; Designer2 [33.3%] | 8h | 150 |
| 171 | 6.7 | **Quest System Prototype** | 6d | 2013-12-06 | 2013-12-13 |  | 76d |  |  | Designer1 | 48h | 900 |
| 172 | 6.7.1 | Create quest prototype | 2d | 2013-12-06 | 2013-12-09 |  | 76d | 0d | start no earlier than 2013-12-06 |  |  |  |
| 173 | 6.7.2 | Test quest system prototype | 2d | 2013-12-10 | 2013-12-11 | 172 | 76d | 0d |  |  |  |  |
| 174 | 6.7.3 | Implement feedback from quest prototype | 2d | 2013-12-12 | 2013-12-13 | 173 | 76d |  |  |  |  |  |
| 175 | 6.8 | **Weapon + Stat Tiles Prototype** | 16d | 2013-12-16 | 2014-01-06 |  | 60d |  |  | Designer2 | 128h | 2,400 |
| 176 | 6.8.1 | Create weapons stats, environment stat tile prototypes | 5d | 2013-12-16 | 2013-12-20 |  | 63d | 0d | start no earlier than 2013-12-16 |  |  |  |
| 177 | 6.8.2 | Test weapons, environment tile stats prototypes | 5d | 2013-12-23 | 2013-12-27 | 176 | 63d | 3d |  |  |  |  |
| 178 | 6.8.3 | Implement feedback from traps,environment test | 3d | 2014-01-02 | 2014-01-06 | 177 | 60d |  | start no earlier than 2014-01-02 |  |  |  |
| 179 | 6.9 | **Custom User Quest Prototype** | 7d | 2014-01-07 | 2014-01-15 |  | 53d |  |  | Designer3 | 56h | 1,050 |
| 180 | 6.9.1 | Script user custom quest system prototype | 3d | 2014-01-07 | 2014-01-09 |  | 53d | 0d | start no earlier than 2014-01-07 |  |  |  |
| 181 | 6.9.2 | Test out custom quest prototype | 2d | 2014-01-10 | 2014-01-13 | 180 | 53d | 0d |  |  |  |  |
| 182 | 6.9.3 | Implement feedback from custom quest prototype | 2d | 2014-01-14 | 2014-01-15 | 181 | 53d |  |  |  |  |  |
| 183 | 6.10 | Catch up day | 1d | 2014-01-16 | 2014-01-16 |  | 52d |  | start no earlier than 2014-01-16 | Designer1 [33%]; Designer2 [33%]; Designer3 [33%] | 7.92h | 148.5 |
| 184 | 6.11 | **Custom Character Screen Prototype** | 9d | 2014-01-17 | 2014-01-29 |  | 43d |  |  | Designer1 | 72h | 1,350 |
| 185 | 6.11.1 | Create custom character screen prototype | 4d | 2014-01-17 | 2014-01-22 |  | 43d | 0d | start no earlier than 2014-01-17 |  |  |  |
| 186 | 6.11.2 | Test custom character screen | 2d | 2014-01-23 | 2014-01-24 | 185 | 43d | 0d |  |  |  |  |
| 187 | 6.11.3 | Implement customized character screen test | 3d | 2014-01-27 | 2014-01-29 | 186 | 43d |  |  |  |  |  |
| 188 | 6.12 | **Multiplayer Selection Menu & GUI Prototype** | 11d | 2014-01-30 | 2014-02-13 |  | 32d |  |  | Designer2 | 88h | 1,650 |
| 189 | 6.12.1 | Create multiplayer selection & menu prototype | 5d | 2014-01-30 | 2014-02-05 |  | 32d | 0d | start no earlier than 2014-01-30 |  |  |  |
| 190 | 6.12.2 | Test muliplayer menu/screens prototype | 3d | 2014-02-06 | 2014-02-10 | 189 | 32d | 0d |  |  |  |  |
| 191 | 6.12.3 | implement feedback multiplayer menu prototype | 3d | 2014-02-11 | 2014-02-13 | 190 | 32d |  |  |  |  |  |

| ID | WBS | Task | Duration | Start | Finish | Predecessors | Total slack | Free slack | Constraint | Resources | Work | Cost |
| --- | --- | --- | --- | --- | --- | --- | --- | --- | --- | --- | --- | --- |
| 192 | 6.13 | **Monster Enemies Round 1 Prototypes** | 6d | 2014-02-14 | 2014-02-21 |  | 26d |  |  | Designer3 | 48h | 900 |
| 193 | 6.13.1 | create monster enemy prototypes round 1 | 4d | 2014-02-14 | 2014-02-19 |  | 28d |  | start no earlier than 2014-02-14 |  |  |  |
| 194 | 6.13.2 | test monster enemy scripts | 2d | 2014-02-17 | 2014-02-18 |  | 26d | 0d | start no earlier than 2014-02-17 |  |  |  |
| 195 | 6.13.3 | implement feedback from monster enemy test | 3d | 2014-02-19 | 2014-02-21 | 194 | 26d |  |  |  |  |  |
| 196 | 6.14 | **Monster Enemies Round 2** | 6d | 2014-02-24 | 2014-03-03 |  | 20d |  |  | Designer1 | 48h | 900 |
| 197 | 6.14.1 | create monster enemy prototypes round 2 | 1d | 2014-02-24 | 2014-02-24 |  | 20d | 0d | start no earlier than 2014-02-24 |  |  |  |
| 198 | 6.14.2 | test monster enemy scripts | 2d | 2014-02-25 | 2014-02-26 | 197 | 20d | 0d |  |  |  |  |
| 199 | 6.14.3 | implement feedback from monster enemy test | 3d | 2014-02-27 | 2014-03-03 | 198 | 20d |  |  |  |  |  |
| 200 | 6.15 | **Healing Items Prototype** | 9d | 2014-03-04 | 2014-03-14 |  | 11d |  |  | Designer2 | 72h | 1,350 |
| 201 | 6.15.1 | create healing items prototypes | 5d | 2014-03-04 | 2014-03-10 |  | 11d | 0d | start no earlier than 2014-03-04 |  |  |  |
| 202 | 6.15.2 | test healing items scripts | 2d | 2014-03-11 | 2014-03-12 | 201 | 11d | 0d |  |  |  |  |
| 203 | 6.15.3 | implement feedback from script test | 2d | 2014-03-13 | 2014-03-14 | 202 | 11d |  |  |  |  |  |
| 204 | 6.16 | Catch up day | 1d | 2014-03-17 | 2014-03-17 |  | 10d |  | start no earlier than 2014-03-17 | Designer3 [33%]; Designer1 [33%]; Designer2 [33%] | 7.92h | 148.5 |
| 205 | 6.17 | **Battle System Round 2** | 10d | 2014-03-18 | 2014-03-31 |  | 0d |  |  | Designer1 | 80h | 1,500 |
| 206 | 6.17.1 | Work on stat battles round 2 | 3d | 2014-03-18 | 2014-03-20 |  | 0d |  | start no earlier than 2014-03-18 |  |  |  |
| 207 | 6.17.2 | Test stat battle round 2 | 2d | 2014-03-21 | 2014-03-24 | 206 | 0d |  |  |  |  |  |
| 208 | 6.17.3 | Implement prototype feedback | 5d | 2014-03-25 | 2014-03-31 | 207 | 0d |  |  |  |  |  |
